# 微信自助办理业务系统V1.0-WBS

Schedule from MS Project, 2017-09-01 to 2017-12-08, costs in ¥, A marks actual dates.

## Calendars

- 标准: Mon-Fri 08:00-12:00, 13:00-17:00; Sat-Sun off. Exceptions (off unless hours are given): 2017-10-01 to 2017-10-08.

## Resources

| Resource | Rate |
| --- | --- |
| 客户代表 |  |
| 胡威 | 50 |
| 屈文敏 | 50 |
| 唐锦涛 | 50 |
| 项目组 | 300 |
| 评审组 | 200 |
| 戴迅 | 50 |
| 范战 | 50 |
| 曹嘉俊 | 50 |
| 曾林涛 | 50 |
| 用户代表 |  |

## Schedule

| ID | WBS | Task | Type | Duration | Start | Finish | Complete | Baseline start | Baseline finish | Baseline duration | Resources | Work | Actual work | Cost | Baseline cost | Actual cost |
| --- | --- | --- | --- | --- | --- | --- | --- | --- | --- | --- | --- | --- | --- | --- | --- | --- |
| 1 | 1 | **项目立项** |  | 1d | 2017-09-01 A | 2017-09-01 A | 100% | 2017-09-01 | 2017-09-01 | 1d |  | 8h | 8h | 400 | 400 | 400 |
| 2 | 1.1 | 项目立项（立项申请，立项审批，立项公告） | manual | 1d | 2017-09-01 A | 2017-09-01 A | 100% | 2017-09-01 | 2017-09-01 | 1d | 戴迅 | 8h | 8h | 400 | 400 | 400 |
| 3 | 1.2 | 项目启动（项目章程，项目组成立） | manual | 1d | 2017-09-01 A | 2017-09-01 A | 100% | 2017-09-01 | 2017-09-01 | 1d |  |  |  |  |  |  |
| 4 | 2 | **项目策划阶段** |  | 3d | 2017-09-04 A | 2017-09-06 A | 100% | 2017-09-04 | 2017-09-05 | 3d |  | 104h | 104h | 6,400 | 2,400 | 6,400 |
| 5 | 2.1 | 项目过程定义裁剪 | manual | 1d | 2017-09-04 A | 2017-09-04 A | 100% | 2017-09-04 | 2017-09-04 | 1d | 戴迅 | 8h | 8h | 400 | 400 | 400 |
| 6 | 2.2 | 构造WBS及项目估算 | manual | 2d | 2017-09-05 A | 2017-09-06 A | 100% | 2017-09-05 | 2017-09-05 | 2d | 戴迅 | 16h | 16h | 800 | 800 | 800 |
| 7 | 2.3 | 项目计划（质量保证计划，配置计划，测试计划，项目测量计划) | manual | 3d | 2017-09-04 A | 2017-09-06 A | 100% | 2017-09-04 | 2017-09-04 | 1d | 曾林涛; 胡威; 屈文敏; 戴迅 [50%] | 72h | 72h | 3,600 | 1,200 | 3,600 |
| 8 | 2.4 | 项目计划评审 | manual | 1d | 2017-09-06 A | 2017-09-06 A | 100% |  |  |  | 评审组 | 8h | 8h | 1,600 |  | 1,600 |
| 9 | 3 | **需求阶段** |  | 11d | 2017-09-07 A | 2017-09-21 A | 100% | 2017-09-08 | 2017-09-20 | 9d |  | 160h | 160h | 12,400 | 9,600 | 12,400 |
| 10 | 3.1 | 用户需求说明书 | manual | 7d | 2017-09-07 A | 2017-09-15 A | 100% | 2017-09-05 | 2017-09-11 | 4d | 戴迅 | 56h | 56h | 2,800 | 1,600 | 2,800 |
| 11 | 3.2 | 软件需求说明书 | manual | 8d | 2017-09-08 A | 2017-09-19 A | 100% | 2017-09-12 | 2017-09-18 | 4d | 戴迅 | 64h | 64h | 3,200 | 1,600 | 3,200 |
| 12 | 3.3 | 需求记录表，功能点及项目计划 | manual | 1d | 2017-09-07 A | 2017-09-07 A | 100% | 2017-09-08 | 2017-09-08 | 1d | 戴迅 | 8h | 8h | 400 | 400 | 400 |
| 13 | 3.4 | 用户需求说明书评审会议 | manual | 1d | 2017-09-16 A | 2017-09-16 A | 100% | 2017-09-12 | 2017-09-12 | 1d | 评审组 | 8h | 8h | 1,600 | 1,600 | 1,600 |
| 14 | 3.5 | 软件需求说明书评审 | manual | 1d | 2017-09-20 A | 2017-09-20 A | 100% | 2017-09-19 | 2017-09-19 | 1d | 评审组 | 8h | 8h | 1,600 | 1,600 | 1,600 |
| 15 | 3.6 | 编写需求阶段里程碑报告 | manual | 1d | 2017-09-21 A | 2017-09-21 A | 100% | 2017-09-20 | 2017-09-20 | 1d | 戴迅 [50%] | 8h | 8h | 400 | 400 | 400 |
| 16 | 3.7 | 需求阶段里程碑会议 | manual | 1d | 2017-09-21 A | 2017-09-21 A | 100% | 2017-09-20 | 2017-09-20 | 1d | 项目组 | 8h | 8h | 2,400 | 2,400 | 2,400 |
| 17 | 4 | **设计阶段任务** |  | 10d | 2017-09-12 A | 2017-09-25 A | 100% | 2017-09-15 | 2017-09-22 | 9d |  | 136h | 136h | 10,800 | 12,400 | 10,800 |
| 18 | 4.1 | **详细设计** |  | 9.2d | 2017-09-12 A | 2017-09-25 A | 100% | 2017-09-15 | 2017-09-21 | 8d |  | 112h | 112h | 5,600 | 7,200 | 5,600 |
| 19 | 4.1.1 | 详细设计说明书 | manual | 9.2d | 2017-09-12 A | 2017-09-25 A | 100% | 2017-09-11 | 2017-09-21 | 8d | 范战 | 72h | 72h | 3,600 | 3,200 | 3,600 |
| 20 | 4.1.2 | 数据库设计 | manual | 5d | 2017-09-14 A | 2017-09-20 A | 100% | 2017-09-15 | 2017-09-20 | 5d | 曹嘉俊 | 40h | 40h | 2,000 | 4,000 | 2,000 |
| 21 | 4.2 | 设计阶段详细设计说明书评审会议 | manual | 1d | 2017-09-25 A | 2017-09-25 A | 100% | 2017-09-22 | 2017-09-22 | 1d | 项目组 | 8h | 8h | 2,400 | 2,400 | 2,400 |
| 22 | 4.3 | 设计阶段详细设计里程碑报告编写 | manual | 1d | 2017-09-25 A | 2017-09-25 A | 100% | 2017-09-22 | 2017-09-22 | 1d | 戴迅 [50%] | 8h | 8h | 400 | 400 | 400 |
| 23 | 4.4 | 设计阶段详细设计里程碑会议 | manual | 1d | 2017-09-25 A | 2017-09-25 A | 100% | 2017-09-22 | 2017-09-22 | 1d | 项目组 | 8h | 8h | 2,400 | 2,400 | 2,400 |
| 24 | 5 | **编码和单元测试阶段** |  | 30d | 2017-09-13 A | 2017-10-31 A | 100% | 2017-09-15 | 2017-10-31 | 24d |  | 512h | 512h | 27,600 | 27,200 | 27,600 |
| 25 | 5.1 | **编码** |  | 29d | 2017-09-13 A | 2017-10-30 A | 100% | 2017-09-15 | 2017-10-30 | 23d |  | 496h | 496h | 24,800 | 24,400 | 24,800 |
| 26 | 5.1.1 | **自助缴费** |  | 17d | 2017-09-13 A | 2017-10-12 A | 100% | 2017-09-15 | 2017-10-11 | 6d |  | 152h | 152h | 7,600 | 2,800 | 7,600 |
| 27 | 5.1.1.1 | 编码 | manual | 12d | 2017-09-13 A | 2017-09-28 A | 100% | 2017-09-15 | 2017-09-29 | 4d | 范战 | 96h | 96h | 4,800 | 1,600 | 4,800 |
| 28 | 5.1.1.2 | 单元测试 | manual | 2d | 2017-09-29 A | 2017-09-30 A | 100% | 2017-09-30 | 2017-09-30 | 1d | 范战 | 16h | 16h | 800 | 400 | 800 |
| 29 | 5.1.1.3 | 代码走查 | manual | 1d | 2017-10-09 A | 2017-10-09 A | 100% | 2017-10-09 | 2017-10-09 | 1d | 戴迅 | 8h | 8h | 400 | 400 | 400 |
| 30 | 5.1.1.4 | 代码返工 | manual | 4d | 2017-10-09 A | 2017-10-12 A | 100% | 2017-10-09 | 2017-10-11 | 1d | 范战 | 32h | 32h | 1,600 | 400 | 1,600 |

| ID | WBS | Task | Type | Duration | Start | Finish | Complete | Baseline start | Baseline finish | Baseline duration | Constraint | Resources | Work | Actual work | Cost | Baseline cost | Actual cost |
| --- | --- | --- | --- | --- | --- | --- | --- | --- | --- | --- | --- | --- | --- | --- | --- | --- | --- |
| 31 | 5.1.2 | **新户办理** |  | 12d | 2017-10-13 A | 2017-10-30 A | 100% | 2017-10-12 | 2017-10-30 | 17d |  |  | 112h | 112h | 5,600 | 11,200 | 5,600 |
| 32 | 5.1.2.1 | 编码 | manual | 9d | 2017-10-13 A | 2017-10-25 A | 100% | 2017-10-12 | 2017-10-24 | 18d |  | 范战 | 72h | 72h | 3,600 | 9,200 | 3,600 |
| 33 | 5.1.2.2 | 单元测试 | manual | 2d | 2017-10-26 A | 2017-10-27 A | 100% | 2017-10-25 | 2017-10-25 | 1d |  | 范战 | 16h | 16h | 800 | 400 | 800 |
| 34 | 5.1.2.3 | 代码走查 | manual | 1d | 2017-10-28 A | 2017-10-28 A | 100% | 2017-10-26 | 2017-10-26 | 1d |  | 戴迅 | 8h | 8h | 400 | 400 | 400 |
| 35 | 5.1.2.4 | 代码返工 | manual | 2d | 2017-10-27 A | 2017-10-30 A | 100% | 2017-10-27 | 2017-10-30 | 3d |  | 范战 | 16h | 16h | 800 | 1,200 | 800 |
| 36 | 5.1.3 | **后续流程（新户办理）** |  | 14d | 2017-09-29 A | 2017-10-25 A | 100% | 2017-10-09 | 2017-10-25 | 12d |  |  | 128h | 128h | 6,400 | 5,600 | 6,400 |
| 37 | 5.1.3.1 | 编码 | manual | 11d | 2017-09-29 A | 2017-10-20 A | 100% | 2017-10-09 | 2017-10-20 | 10d |  | 曹嘉俊 | 88h | 88h | 4,400 | 4,000 | 4,400 |
| 38 | 5.1.3.2 | 单元测试 | manual | 1d | 2017-10-23 A | 2017-10-23 A | 100% | 2017-10-21 | 2017-10-21 | 1d |  | 曹嘉俊 | 8h | 8h | 400 | 400 | 400 |
| 39 | 5.1.3.3 | 代码走查 | manual | 1d | 2017-10-24 A | 2017-10-24 A | 100% | 2017-10-23 | 2017-10-23 | 1d |  | 戴迅 | 8h | 8h | 400 | 400 | 400 |
| 40 | 5.1.3.4 | 代码返工 | manual | 3d | 2017-10-23 A | 2017-10-25 A | 100% | 2017-10-23 | 2017-10-25 | 2d |  | 曹嘉俊 | 24h | 24h | 1,200 | 800 | 1,200 |
| 41 | 5.1.4 | **办理分机** |  | 12d | 2017-09-13 A | 2017-09-28 A | 100% | 2017-09-15 | 2017-09-29 | 11d |  |  | 104h | 104h | 5,200 | 4,800 | 5,200 |
| 42 | 5.1.4.1 | 编码 | manual | 8d | 2017-09-13 A | 2017-09-22 A | 100% | 2017-09-15 | 2017-09-25 | 7d |  | 曹嘉俊 | 64h | 64h | 3,200 | 2,800 | 3,200 |
| 43 | 5.1.4.2 | 单元测试 | manual | 1d | 2017-09-25 A | 2017-09-25 A | 100% | 2017-09-27 | 2017-09-27 | 2d |  | 曹嘉俊 | 8h | 8h | 400 | 800 | 400 |
| 44 | 5.1.4.3 | 代码走查 | manual | 1d | 2017-09-26 A | 2017-09-26 A | 100% | 2017-09-28 | 2017-09-28 | 1d |  | 戴迅 | 8h | 8h | 400 | 400 | 400 |
| 45 | 5.1.4.4 | 代码返工 | manual | 3d | 2017-09-26 A | 2017-09-28 A | 100% | 2017-09-29 | 2017-09-29 | 2d |  | 曹嘉俊 | 24h | 24h | 1,200 | 800 | 1,200 |
| 46 | 5.2 | 编码阶段里程碑报告编写 | manual | 1d | 2017-10-31 A | 2017-10-31 A | 100% | 2017-10-31 | 2017-10-31 | 1d |  | 戴迅 [50%] | 8h | 8h | 400 | 400 | 400 |
| 47 | 5.3 | 编码阶段里程碑会议 | manual | 1d | 2017-10-31 A | 2017-10-31 A | 100% | 2017-10-31 | 2017-10-31 | 1d |  | 项目组 | 8h | 8h | 2,400 | 2,400 | 2,400 |
| 48 | 6 | **集成及测试阶段** |  | 30d | 2017-09-25 A | 2017-11-10 A | 100% | 2017-09-25 | 2017-11-07 | 25d |  |  | 320h | 320h | 21,600 | 19,600 | 21,600 |
| 49 | 6.1 | **系统测试** |  | 26d | 2017-09-25 A | 2017-11-06 A | 100% | 2017-09-25 | 2017-10-31 | 21d |  |  | 248h | 248h | 13,600 | 12,000 | 13,600 |
| 50 | 6.1.1 | 测试用例 | manual | 7d | 2017-09-25 A | 2017-10-10 A | 100% | 2017-09-25 | 2017-10-11 | 7d |  | 曾林涛 | 96h | 96h | 4,800 | 4,800 | 4,800 |
| 51 | 6.1.2 | 测试用例评审 | manual | 1d | 2017-10-11 A | 2017-10-11 A | 100% | 2017-10-12 | 2017-10-12 | 1d |  | 评审组 | 8h | 8h | 1,600 | 1,600 | 1,600 |
| 52 | 6.1.3 | 第一轮测试 | manual | 10d | 2017-10-12 A | 2017-10-25 A | 100% | 2017-10-13 | 2017-10-25 | 7d |  | 曾林涛 | 80h | 80h | 4,000 | 2,800 | 4,000 |
| 53 | 6.1.4 | 第二轮测试 | manual | 7d | 2017-10-26 A | 2017-11-03 A | 100% | 2017-10-26 | 2017-10-30 | 6d | start no earlier than 2017-10-26 | 曾林涛 | 56h | 56h | 2,800 | 2,400 | 2,800 |
| 54 | 6.1.5 | 系统测试报告编写 | manual | 1d | 2017-11-06 A | 2017-11-06 A | 100% | 2017-10-31 | 2017-10-31 | 1d |  | 曾林涛 | 8h | 8h | 400 | 400 | 400 |

| ID | WBS | Task | Type | Duration | Start | Finish | Complete | Baseline start | Baseline finish | Baseline duration | Constraint | Resources | Work | Actual work | Cost | Baseline cost | Actual cost |
| --- | --- | --- | --- | --- | --- | --- | --- | --- | --- | --- | --- | --- | --- | --- | --- | --- | --- |
| 55 | 6.2 | **用户手册** |  | 5d | 2017-11-06 A | 2017-11-10 A | 100% | 2017-11-03 | 2017-11-07 | 3d |  |  | 48h | 48h | 3,600 | 3,200 | 3,600 |
| 56 | 6.2.1 | 用户手册编写（用户安装手册，用户操作手册） | manual | 3d | 2017-11-06 A | 2017-11-08 A | 100% | 2017-11-02 | 2017-11-06 | 3d |  | 曾林涛 | 24h | 24h | 1,200 | 1,200 | 1,200 |
| 57 | 6.2.2 | 用户手册评审 | manual | 1d | 2017-11-09 A | 2017-11-09 A | 100% | 2017-11-07 | 2017-11-07 | 1d |  | 评审组 | 8h | 8h | 1,600 | 1,600 | 1,600 |
| 58 | 6.2.3 | 用户手册返工 | manual | 2d | 2017-11-09 A | 2017-11-10 A | 100% | 2017-11-07 | 2017-11-07 | 1d |  | 曾林涛 | 16h | 16h | 800 | 400 | 800 |
| 59 | 6.3 | 测试阶段评审会议 | manual | 1d | 2017-11-07 A | 2017-11-07 A | 100% | 2017-11-01 | 2017-11-01 | 1d |  | 评审组 | 8h | 8h | 1,600 | 1,600 | 1,600 |
| 60 | 6.4 | 编写测试阶段里程碑报告 | manual | 1d | 2017-11-08 A | 2017-11-08 A | 100% | 2017-11-01 | 2017-11-01 | 1d |  | 戴迅 [50%] | 8h | 8h | 400 | 400 | 400 |
| 61 | 6.5 | 测试阶段里程碑会议 | manual | 1d | 2017-11-08 A | 2017-11-08 A | 100% | 2017-11-01 | 2017-11-01 | 1d | start no earlier than 2017-11-08 | 项目组 | 8h | 8h | 2,400 | 2,400 | 2,400 |
| 62 | 7 | **试运行** |  | 10d | 2017-11-13 A | 2017-11-24 A | 100% | 2017-11-03 | 2017-11-09 | 5d |  |  | 136h | 136h | 5,600 | 3,600 | 5,600 |
| 63 | 7.1 | **系统安装** |  | 1d | 2017-11-13 A | 2017-11-13 A | 100% | 2017-11-03 | 2017-11-03 | 1d |  |  | 8h | 8h |  | 800 |  |
| 64 | 7.1.1 | 软件安装 | manual | 1d | 2017-11-13 A | 2017-11-13 A | 100% | 2017-11-03 | 2017-11-03 | 1d |  |  |  |  |  | 400 |  |
| 65 | 7.1.2 | 现场培训 | manual | 1d | 2017-11-13 A | 2017-11-13 A | 100% | 2017-11-03 | 2017-11-03 | 1d |  | 曾林涛 | 8h | 8h |  | 400 |  |
| 66 | 7.2 | 系统试运行 | manual | 5d | 2017-11-14 A | 2017-11-20 A | 100% | 2017-11-03 | 2017-11-09 | 5d |  | 范战 | 40h | 40h | 2,000 | 2,000 | 2,000 |
| 67 | 7.3 | 试运行问题收集 | manual | 4d | 2017-11-15 A | 2017-11-20 A | 100% | 2017-11-09 | 2017-11-09 | 1d |  | 曾林涛 | 32h | 32h | 1,600 | 400 | 1,600 |
| 68 | 7.4 | 试运行问题维护 | manual | 4d | 2017-11-17 A | 2017-11-22 A | 100% | 2017-11-09 | 2017-11-09 | 0d |  | 范战 | 32h | 32h | 1,600 |  | 1,600 |
| 69 | 7.5 | 试运行情况汇报 | manual | 1d | 2017-11-22 A | 2017-11-22 A | 100% | 2017-11-09 | 2017-11-09 | 1d |  | 范战 | 8h | 8h | 400 | 400 | 400 |
| 70 | 7.6 | 试运行报告签署 | manual | 2d | 2017-11-23 A | 2017-11-24 A | 100% | 2017-11-09 | 2017-11-09 | 1d |  | 用户代表 | 16h | 16h |  |  |  |
| 71 | 8 | **项目验收及移交** |  | 9d | 2017-11-27 A | 2017-12-07 A | 100% | 2017-11-10 | 2017-11-29 | 5d |  |  | 112h | 112h | 10,000 | 9,600 | 10,000 |
| 72 | 8.1 | **项目验收** |  | 7d | 2017-11-27 A | 2017-12-05 A | 100% | 2017-11-10 | 2017-11-27 | 5d |  |  | 72h | 72h | 6,400 | 6,000 | 6,400 |
| 73 | 8.1.1 | 验收申请 | manual | 1d | 2017-11-27 A | 2017-11-27 A | 100% | 2017-11-10 | 2017-11-10 | 1d |  | 戴迅 [50%] | 8h | 8h | 400 | 400 | 400 |
| 74 | 8.1.2 | 制订验收计划、验收测试计划、验收测试用例编写 | manual | 3d | 2017-11-27 A | 2017-11-29 A | 100% | 2017-11-13 | 2017-11-17 | 2d |  | 戴迅 | 24h | 24h | 1,200 | 800 | 1,200 |
| 75 | 8.1.3 | 验收准备 | manual | 2d | 2017-11-29 A | 2017-11-30 A | 100% | 2017-11-20 | 2017-11-20 | 2d |  | 项目组 | 16h | 16h | 4,800 | 4,800 | 4,800 |
| 76 | 8.1.4 | 验收测试、系统验收 | manual | 2d | 2017-12-01 A | 2017-12-04 A | 100% | 2017-11-21 | 2017-11-24 | 3d | start no earlier than 2017-12-01 | 用户代表 | 16h | 16h |  |  |  |
| 77 | 8.1.5 | 验收测试报告、验收报告签署 | manual | 1d | 2017-12-05 A | 2017-12-05 A | 100% | 2017-11-27 | 2017-11-27 | 1d | start no earlier than 2017-12-05 | 用户代表 | 8h | 8h |  |  |  |
| 78 | 8.2 | **项目移交** |  | 1d | 2017-12-06 A | 2017-12-06 A | 100% | 2017-11-29 | 2017-11-29 | 1d |  |  | 16h | 16h | 800 | 800 | 800 |
| 79 | 8.2.1 | 确定移交事项 | manual | 1d | 2017-12-06 A | 2017-12-06 A | 100% | 2017-11-29 | 2017-11-29 | 1d |  | 曹嘉俊 [50%] | 8h | 8h | 400 | 400 | 400 |
| 80 | 8.2.2 | 移交项目技术资料 | manual | 1d | 2017-12-06 A | 2017-12-06 A | 100% | 2017-11-29 | 2017-11-29 | 1d |  | 曹嘉俊 [50%] | 8h | 8h | 400 | 400 | 400 |
| 81 | 8.3 | 编写验收阶段里程碑报告 | manual | 1d | 2017-12-07 A | 2017-12-07 A | 100% | 2017-11-28 | 2017-11-28 | 1d |  | 戴迅 [50%] | 8h | 8h | 400 | 400 | 400 |
| 82 | 8.4 | 验收阶段里程碑会议 | manual | 1d | 2017-12-07 A | 2017-12-07 A | 100% | 2017-11-28 | 2017-11-28 | 1d |  | 项目组; 用户代表 | 16h | 16h | 2,400 | 2,400 | 2,400 |

| ID | WBS | Task | Type | Duration | Start | Finish | Complete | Baseline start | Baseline finish | Baseline duration | Constraint | Resources | Work | Actual work | Cost | Baseline cost | Actual cost |
| --- | --- | --- | --- | --- | --- | --- | --- | --- | --- | --- | --- | --- | --- | --- | --- | --- | --- |
| 83 | 9 | **结项** |  | 2d | 2017-12-07 A | 2017-12-08 A | 100% | 2017-11-30 | 2017-12-01 | 1d |  |  | 16h | 16h | 2,800 | 2,800 | 2,800 |
| 84 | 9.1 | 项目经理提交项目总结报告 | manual | 1d | 2017-12-07 A | 2017-12-07 A | 100% | 2017-11-30 | 2017-11-30 | 1d |  | 戴迅 [50%] | 8h | 8h | 400 | 400 | 400 |
| 85 | 9.2 | 召开项目总结会议 | manual | 1d | 2017-12-08 A | 2017-12-08 A | 100% | 2017-12-01 | 2017-12-01 | 1d |  | 项目组 | 8h | 8h | 2,400 | 2,400 | 2,400 |
| 86 | 10 | **项目跟踪与监控** |  | 66d? | 2017-09-01 A | 2017-12-08 A | 100% | 2017-09-01 | 2017-11-15 | 46d |  |  | 168h | 168h | 19,600 | 18,000 | 19,600 |
| 87 | 10.1 | **项目例会** |  | 66d | 2017-09-01 A | 2017-12-08 A | 100% | 2017-09-01 | 2017-11-15 | 41d |  |  | 56h | 56h | 14,400 | 16,800 | 14,400 |
| 88 | 10.1.1 | 项目例会 1（风险、度量等） | manual | 1d | 2017-09-01 A | 2017-09-01 A | 100% | 2017-09-01 | 2017-09-01 | 1d |  | 项目组 | 8h | 8h |  |  |  |
| 89 | 10.1.2 | 项目例会 2（风险、度量等） | manual | 1d | 2017-09-15 A | 2017-09-15 A | 100% | 2017-09-15 | 2017-09-15 | 0d | start no earlier than 2017-09-15 | 项目组 | 8h | 8h | 2,400 |  | 2,400 |
| 90 | 10.1.3 | 项目例会 3（风险、度量等） | manual | 1d | 2017-10-16 A | 2017-10-16 A | 100% | 2017-09-30 | 2017-09-30 | 1d |  | 项目组 | 8h | 8h | 2,400 | 2,400 | 2,400 |
| 91 | 10.1.4 | 项目例会 4（风险、度量等） | manual | 1d | 2017-11-01 A | 2017-11-01 A | 100% | 2017-10-21 | 2017-10-21 | 1d |  | 项目组 | 8h | 8h | 2,400 | 2,400 | 2,400 |
| 92 | 10.1.5 | 项目例会 5（风险、度量等） | manual | 1d | 2017-11-17 A | 2017-11-17 A | 100% | 2017-11-03 | 2017-11-03 | 1d |  | 项目组 | 8h | 8h | 2,400 | 2,400 | 2,400 |
| 93 | 10.1.6 | 项目例会 6（风险、度量等） | manual | 1d | 2017-12-01 A | 2017-12-01 A | 100% | 2017-11-17 | 2017-11-17 | 0d |  | 项目组 | 8h | 8h | 2,400 |  | 2,400 |
| 94 | 10.1.7 | 项目例会 7（风险、度量等） | manual | 1d | 2017-12-08 A | 2017-12-08 A | 100% | 2017-12-01 | 2017-12-01 | 0d |  | 项目组 | 8h | 8h | 2,400 |  | 2,400 |
| 95 | 10.2 | **项目管理、需求分析** |  | 46d | 2017-09-15 A | 2017-11-24 A | 100% | 2017-09-15 | 2017-11-24 | 26d |  |  | 32h | 32h | 1,200 | 1,200 | 1,200 |
| 96 | 10.2.1 | 需求、项目管理一 | manual | 1d | 2017-09-15 A | 2017-09-15 A | 100% | 2017-09-15 | 2017-09-15 | 1d |  | 戴迅 | 8h | 8h |  |  |  |
| 97 | 10.2.2 | 需求、项目管理二 | manual | 1d | 2017-09-30 A | 2017-09-30 A | 100% | 2017-09-30 | 2017-09-30 | 1d |  | 戴迅 | 8h | 8h | 400 | 400 | 400 |
| 98 | 10.2.3 | 需求、项目管理三 | manual | 1d | 2017-10-31 A | 2017-10-31 A | 100% | 2017-10-31 | 2017-10-31 | 1d |  | 戴迅 | 8h | 8h | 400 | 400 | 400 |
| 99 | 10.2.4 | 需求、项目管理四 | manual | 1d | 2017-11-24 A | 2017-11-24 A | 100% | 2017-11-24 | 2017-11-24 | 1d |  | 戴迅 | 8h | 8h | 400 | 400 | 400 |
| 100 | 10.3 | **QA工作** |  | 52d? | 2017-09-21 A | 2017-12-08 A | 100% | 2017-09-01 | 2017-12-01 | 46d |  |  | 40h | 40h | 2,000 |  | 2,000 |
| 101 | 10.3.1 | **质保管理** |  | 52d? | 2017-09-21 A | 2017-12-08 A | 100% | 2017-09-01 | 2017-12-01 | 0d |  |  | 40h | 40h | 2,000 |  | 2,000 |
| 102 | 10.3.1.1 | 需求阶段质保检查 | manual | 1d | 2017-09-21 A | 2017-09-21 A | 100% | 2017-09-20 | 2017-09-20 | 0d |  | 屈文敏 | 8h | 8h | 400 |  | 400 |
| 103 | 10.3.1.2 | 设计阶段质保检查 | manual | 1d? | 2017-09-25 A | 2017-09-25 A | 100% | 2017-09-22 | 2017-09-22 | 0d |  | 屈文敏 | 8h | 8h | 400 |  | 400 |
| 104 | 10.3.1.3 | 编码阶段质保检查 | manual | 1d? | 2017-10-31 A | 2017-10-31 A | 100% | 2017-10-31 | 2017-10-31 | 0d |  | 屈文敏 | 8h | 8h | 400 |  | 400 |
| 105 | 10.3.1.4 | 测试阶段质保检查 | manual | 1d? | 2017-11-10 A | 2017-11-10 A | 100% | 2017-11-07 | 2017-11-07 | 0d |  | 屈文敏 | 8h | 8h | 400 |  | 400 |
| 106 | 10.3.1.5 | 验收阶段质保检查 | manual | 1d? | 2017-12-08 A | 2017-12-08 A | 100% | 2017-12-01 | 2017-12-01 | 0d |  | 屈文敏 | 8h | 8h | 400 |  | 400 |

| ID | WBS | Task | Type | Duration | Start | Finish | Complete | Baseline start | Baseline finish | Baseline duration | Resources | Work | Actual work | Cost | Actual cost |
| --- | --- | --- | --- | --- | --- | --- | --- | --- | --- | --- | --- | --- | --- | --- | --- |
| 107 | 10.4 | **CM工作** |  | 51d | 2017-09-22 A | 2017-12-08 A | 100% | 2017-09-01 | 2017-11-01 | 46d |  | 40h | 40h | 2,000 | 2,000 |
| 108 | 10.4.1 | **配置报告** |  | 51d | 2017-09-22 A | 2017-12-08 A | 100% | 2017-09-20 | 2017-12-15 |  |  | 40h | 40h | 2,000 | 2,000 |
| 109 | 10.4.1.1 | 需求阶段CM活动报告和基线管理 | manual | 1d | 2017-09-22 A | 2017-09-22 A | 100% | 2017-09-21 | 2017-09-21 |  | 胡威 | 8h | 8h | 400 | 400 |
| 110 | 10.4.1.2 | 设计阶段CM活动报告和基线管理 | manual | 1d | 2017-09-26 A | 2017-09-26 A | 100% | 2017-09-25 | 2017-09-25 | 0d | 胡威 | 8h | 8h | 400 | 400 |
| 111 | 10.4.1.3 | 实现阶段CM活动报告和基线管理 | manual | 1d | 2017-11-01 A | 2017-11-01 A | 100% | 2017-11-01 | 2017-11-01 | 0d | 胡威 | 8h | 8h | 400 | 400 |
| 112 | 10.4.1.4 | 测试阶段CM活动报告和基线管理 | manual | 1d | 2017-11-13 A | 2017-11-13 A | 100% | 2017-11-08 | 2017-11-08 | 0d | 胡威 | 8h | 8h | 400 | 400 |
| 113 | 10.4.1.5 | 验收阶段CM活动报告和基线管理 | manual | 1d | 2017-12-08 A | 2017-12-08 A | 100% | 2017-12-01 | 2017-12-01 | 0d | 胡威 | 8h | 8h | 400 | 400 |
